# Office implementation schedule

Schedule from MS Project, 2026-10-05 to 2027-06-28.
R02
PLANORA
Conceptual scenario for one 8,000 sq ft office. Illustrative start 5 October 2026. Actual site, approvals, supplier commitments and construction authorization unconfirmed.

## Calendars

- Estándar: Mon-Fri 08:00-12:00, 13:00-17:00; Sat-Sun off. Exceptions (off unless hours are given): 2026-11-26 (Illustrative Thanksgiving closure), 2026-11-27 (Illustrative year-end closure), 2026-12-24 to 2026-12-25 (Illustrative year-end closure), 2027-01-01 (Illustrative New Year closure), 2027-05-31 (Illustrative spring closure).

## Resources

| Resource |
| --- |
| Site support crew |
| Partition crew |
| Electrical crew |
| HVAC crew |
| Sprinkler crew |
| Alarm specialist crew |
| Data and AV crew |
| Plumbing crew |
| Painting crew |
| Ceiling crew |
| Flooring crew A |
| Glazing crew |
| Millwork crew |
| Logistics vendor crew |
| Furniture installation crew |
| Flooring crew B |
| IT deployment vendor |

## Schedule

| ID | WBS | Task | Type | Duration | Start | Finish | Predecessors | Total slack | Free slack | Resources | Work | Text1 | Text2 | Text3 |
| --- | --- | --- | --- | --- | --- | --- | --- | --- | --- | --- | --- | --- | --- | --- |
| 1 | 1 | **01 Definition and approvals** |  | 68d? | 2026-10-05 | 2027-01-13 |  | 0d |  |  |  |  |  |  |
| 2 | 1.1 | Preconstruction authorization | milestone | 0d | 2026-10-05 | 2026-10-05 |  | 0d |  |  |  | START | Coordination / waiting | Whole office |
| 3 | 1.2 | Existing conditions and capacity survey |  | 5d? | 2026-10-05 | 2026-10-09 | 2 | 0d |  |  |  | SURVEY | Coordination / waiting | Whole office |
| 4 | 1.3 | Coordinated architectural and MEP design |  | 15d? | 2026-10-12 | 2026-10-30 | 3 | 0d |  |  |  | DESIGN | Coordination / waiting | Whole office |
| 5 | 1.4 | Permit documentation and submission |  | 10d? | 2026-11-02 | 2026-11-13 | 4 | 0d |  |  |  | DOCS | Coordination / waiting | Whole office |
| 6 | 1.5 | Landlord design and access review |  | 10d? | 2026-11-16 | 2026-12-01 | 5 | 18.59d | 5d |  |  | LANDLORD | Coordination / waiting | Whole office |
| 7 | 1.6 | Authority first review |  | 20d? | 2026-11-16 | 2026-12-15 | 5 | 0d |  |  |  | REVIEW | Coordination / waiting | Whole office |
| 8 | 1.7 | Coordinated response to comments |  | 5d? | 2026-12-16 | 2026-12-22 | 7 | 0d |  |  |  | COMMENTS | Coordination / waiting | Whole office |
| 9 | 1.8 | Authority review of corrections |  | 10d? | 2026-12-23 | 2027-01-08 | 8 | 0d |  |  |  | REREVIEW | Coordination / waiting | Whole office |
| 10 | 1.9 | Permit and trade permit issuance |  | 3d? | 2027-01-11 | 2027-01-13 | 9, 6 | 0d |  |  |  | PERMIT | Coordination / waiting | Whole office |
| 11 | 1.10 | Trade bids and scope reconciliation |  | 10d? | 2026-11-16 | 2026-12-01 | 5 | 13.59d | 0d |  |  | BID | Coordination / waiting | Whole office |
| 12 | 1.11 | Contract awards and purchase authorization |  | 5d? | 2026-12-02 | 2026-12-08 | 11 | 13.59d | 0d |  |  | AWARD | Coordination / waiting | Whole office |
| 13 | 2 | **02 Procurement and mobilization** |  | 55d? | 2026-12-09 | 2027-02-26 |  | 13.59d |  |  |  |  |  |  |
| 14 | 2.1 | Shop drawings, samples and interface approval |  | 10d? | 2026-12-09 | 2026-12-22 | 12, 6 | 13.59d | 0d |  |  | SUBMIT | Coordination / waiting | Whole office |
| 15 | 2.2 | Glazing and door fabrication / delivery |  | 35d? | 2026-12-23 | 2027-02-12 | 14 | 45.54d |  |  |  | GLASSBUY | Coordination / waiting | Whole office |
| 16 | 2.3 | Millwork fabrication / delivery |  | 45d? | 2026-12-23 | 2027-02-26 | 14 | 36.01d |  |  |  | MILLBUY | Coordination / waiting | Whole office |
| 17 | 2.4 | Furniture and equipment availability |  | 40d? | 2026-12-23 | 2027-02-19 | 14 | 60.07d | 51.92d |  |  | FURNBUY | Coordination / waiting | Whole office |
| 18 | 2.5 | MEP rough-in material availability |  | 10d? | 2026-12-23 | 2027-01-08 | 14 | 15.41d |  |  |  | MEPBUY | Coordination / waiting | Whole office |
| 19 | 2.6 | Ceiling, flooring and fixture availability |  | 30d? | 2026-12-23 | 2027-02-05 | 14 | 13.59d |  |  |  | FINBUY | Coordination / waiting | Whole office |
| 20 | 2.7 | Service order and provider readiness |  | 30d? | 2026-12-09 | 2027-01-22 | 12 | 105.33d |  |  |  | ISP | Coordination / waiting | Whole office |
| 21 | 2.8 | Computers, appliances and shared equipment |  | 25d? | 2026-12-09 | 2027-01-15 | 12 | 93.95d | 74.21d |  |  | EQUIPBUY | Coordination / waiting | Whole office |
| 22 | 2.9 | Building access and mobilization arrangements |  | 3d? | 2027-01-14 | 2027-01-18 | 10, 12 | 0d |  |  |  | MOBREADY | Coordination / waiting | Whole office |
| 23 | 3 | **03 Construction and fit-out** |  | 94d? | 2027-01-19 | 2027-05-28 |  | 0d |  |  | 5159.92h |  |  |  |
| 24 | 3.1 | Temporary protection and dust control |  | 1.5d? | 2027-01-19 | 2027-01-20 | 22 | 0d |  | Site support crew [400%] | 48h | PROTECT | P26 | Whole office |
| 25 | 3.2 | Selective demolition and disposal |  | 5d? | 2027-01-20 | 2027-01-27 | 24 | 0d |  | Site support crew [400%] | 160h | DEMO | P26 | Whole office |
| 26 | 3.3 | Penetrations, supports and firestops |  | 1d? | 2027-01-27 | 2027-01-28 | 25 | 0d |  | Site support crew [400%] | 32h | SUPPORT | P26 | Whole office |
| 27 | 3.4 | Partition framing and backing / Zone One |  | 1.91d? | 2027-01-28 | 2027-02-01 | 26 | 0d |  | Partition crew [400%] | 61.13h | FRAMEA | P01 | Zone One |
| 28 | 3.5 | Electrical rough-in / Zone One |  | 8.9d? | 2027-02-01 | 2027-02-12 | 27, 18 | 0d |  | Electrical crew [300%] | 213.71h | ELECROUGHA | P20 | Zone One |
| 29 | 3.6 | HVAC distribution and controls rough-in / Zone One |  | 7.33d? | 2027-02-01 | 2027-02-10 | 27, 18 | 1.99d | 0d | HVAC crew [300%] | 176h | HVACROUGHA | P21 | Zone One |
| 30 | 3.7 | Sprinkler branch work and drops / Zone One |  | 3.64d? | 2027-02-01 | 2027-02-05 | 27, 18 | 5.31d | 0d | Sprinkler crew [200%] | 58.25h | SPRROUGHA | P23S | Zone One |
| 31 | 3.8 | Alarm cabling and system interfaces / Zone One |  | 2.19d? | 2027-02-01 | 2027-02-03 | 27, 18 | 7.13d | 0d | Alarm specialist crew [200%] | 35h | ALARMROUGHA | P23A | Zone One |
| 32 | 3.9 | Data pathways and cabling / Zone One |  | 2.26d? | 2027-02-01 | 2027-02-03 | 27 | 7.06d | 0d | Data and AV crew [200%] | 36.2h | DATAROUGHA | P24 | Zone One |
| 33 | 3.10 | Electrical checks before concealment / Zone One |  | 0.42d? | 2027-02-12 | 2027-02-12 | 28 | 0d |  | Electrical crew [300%] | 10h | POWERCONCEALA | P20 | Zone One |
| 34 | 3.11 | Sprinkler checks before concealment / Zone One |  | 0.38d? | 2027-02-05 | 2027-02-05 | 30 | 5.31d | 0d | Sprinkler crew [200%] | 6h | SPRCONCEALA | P23S | Zone One |
| 35 | 3.12 | Partition framing and backing / Zone Two |  | 1.91d? | 2027-02-01 | 2027-02-03 | 26, 27 | 9.41d | 0.28d | Partition crew [400%] | 61.13h | FRAMEB | P01 | Zone Two |
| 36 | 3.13 | Electrical rough-in / Zone Two |  | 8.9d? | 2027-02-12 | 2027-02-25 | 35, 18, 28, 33 | 2.06d | 0d | Electrical crew [300%] | 213.71h | ELECROUGHB | P20 | Zone Two |
| 37 | 3.14 | HVAC distribution and controls rough-in / Zone Two |  | 7.33d? | 2027-02-10 | 2027-02-22 | 35, 18, 29 | 6.04d | 3.98d | HVAC crew [300%] | 176h | HVACROUGHB | P21 | Zone Two |
| 38 | 3.15 | Sprinkler branch work and drops / Zone Two |  | 3.64d? | 2027-02-05 | 2027-02-11 | 35, 18, 30, 34 | 12.68d | 0d | Sprinkler crew [200%] | 58.25h | SPRROUGHB | P23S | Zone Two |
| 39 | 3.16 | Alarm cabling and system interfaces / Zone Two |  | 2.19d? | 2027-02-03 | 2027-02-05 | 35, 18, 31 | 16.33d | 14.27d | Alarm specialist crew [200%] | 35h | ALARMROUGHB | P23A | Zone Two |
| 40 | 3.17 | Data pathways and cabling / Zone Two |  | 2.26d? | 2027-02-03 | 2027-02-05 | 35, 32 | 16.18d | 14.12d | Data and AV crew [200%] | 36.2h | DATAROUGHB | P24 | Zone Two |
| 41 | 3.18 | Electrical checks before concealment / Zone Two |  | 0.42d? | 2027-02-25 | 2027-02-26 | 36 | 2.06d | 0d | Electrical crew [300%] | 10h | POWERCONCEALB | P20 | Zone Two |
| 42 | 3.19 | Sprinkler checks before concealment / Zone Two |  | 0.38d? | 2027-02-11 | 2027-02-11 | 38 | 12.68d | 10.61d | Sprinkler crew [200%] | 6h | SPRCONCEALB | P23S | Zone Two |
| 43 | 3.20 | Pantry pipework and rough-in |  | 4.38d? | 2027-02-01 | 2027-02-05 | 27, 18 | 4.45d | 0d | Plumbing crew [200%] | 70h | PLUMBROUGH | P22 | Whole office |
| 44 | 3.21 | Pantry pre-concealment testing |  | 0.5d? | 2027-02-05 | 2027-02-08 | 43 | 4.45d |  | Plumbing crew [200%] | 8h | PLUMBCONCEAL | P22 | Whole office |
| 45 | 3.22 | Concealed-work inspections / Zone One |  | 2d? | 2027-02-12 | 2027-02-16 | 33, 29, 34, 31, 32, 44 | 0d |  |  |  | ROUGHA | Coordination / waiting | Zone One |
| 46 | 3.23 | Insulation and partition closure / Zone One |  | 2.38d? | 2027-02-16 | 2027-02-19 | 45, 35 | 0d |  | Partition crew [400%] | 76.26h | CLOSEA | P01 | Zone One |
| 47 | 3.24 | Joint treatment and wall finishing / Zone One |  | 0.87d? | 2027-02-19 | 2027-02-19 | 46 | 0d |  | Partition crew [400%] | 27.71h | JOINTA | P01 | Zone One |
| 48 | 3.25 | Drying and substrate acceptance / Zone One |  | 2d? | 2027-02-19 | 2027-02-23 | 47 | 0d |  |  |  | DRYA | Coordination / waiting | Zone One |
| 49 | 3.26 | Painting and finish protection / Zone One |  | 1.61d? | 2027-02-23 | 2027-02-25 | 48 | 0d |  | Painting crew [300%] | 38.57h | PAINTA | P09 | Zone One |
| 50 | 3.27 | Ceiling grid and tiles / Zone One |  | 4.64d? | 2027-02-25 | 2027-03-04 | 49, 19 | 0d |  | Ceiling crew [300%] | 111.32h | CEILA | P05 | Zone One |
| 51 | 3.28 | Suspended acoustic baffles / Zone One |  | 1.88d? | 2027-03-04 | 2027-03-08 | 50 | 0d |  | Ceiling crew [300%] | 45h | BAFFLEA | P06 | Zone One |
| 52 | 3.29 | Floor preparation and patching / Zone One |  | 2.5d? | 2027-03-08 | 2027-03-10 | 51 | 0d |  | Flooring crew A [300%] | 60h | PREPFLOORA | P07 | Zone One |
| 53 | 3.30 | Porcelain floor installation / Zone One |  | 23.78d? | 2027-03-10 | 2027-04-13 | 52 | 0d |  | Flooring crew A [300%] | 570.78h | TILEA | P07 | Zone One |
| 54 | 3.31 | Floor cure and finish acceptance / Zone One |  | 2d? | 2027-04-13 | 2027-04-15 | 53 | 0d |  |  |  | CUREA | Coordination / waiting | Zone One |
| 55 | 3.32 | Carpet tile and transitions / Zone One |  | 2.15d? | 2027-04-15 | 2027-04-19 | 54 | 0d |  | Flooring crew A [300%] | 51.66h | CARPETA | P08 | Zone One |
| 56 | 3.33 | Glazed partitions and seals / Zone One |  | 7.8d? | 2027-04-19 | 2027-04-29 | 55, 15 | 3.42d | 0d | Glazing crew [300%] | 187.24h | GLASSA | P02 | Zone One |
| 57 | 3.34 | Glass doors and hardware / Zone One |  | 1.88d? | 2027-04-29 | 2027-05-03 | 56 | 3.42d | 0d | Glazing crew [200%] | 30h | GLASSDOORA | P03 | Zone One |
| 58 | 3.35 | Solid doors and hardware / Zone One |  | 0.47d? | 2027-04-19 | 2027-04-20 | 55, 15 | 0d |  | Millwork crew [200%] | 7.5h | SOLIDDOORA | P04 | Zone One |
| 59 | 3.36 | Fixed millwork and pantry joinery / Zone One |  | 5.83d? | 2027-04-20 | 2027-04-27 | 58, 16 | 0d |  | Millwork crew [300%] | 140h | MILLA | P11 | Zone One |
| 60 | 3.37 | Decorative finishes, shading and signs / Zone One |  | 5.08d? | 2027-04-27 | 2027-05-04 | 59 | 0d |  | Millwork crew [300%] | 122h | DECORA | P10 | Zone One |
| 61 | 3.38 | Electrical trim, controls and fixtures / Zone One |  | 4.59d? | 2027-04-19 | 2027-04-26 | 55, 41 | 15.29d | 4.09d | Electrical crew [300%] | 110.1h | ELECTRIMA | P19, P20 | Zone One |
| 62 | 3.39 | Air terminals and controls completion / Zone One |  | 2.33d? | 2027-03-08 | 2027-03-10 | 51, 37 | 51.07d | 6.99d | HVAC crew [300%] | 56h | HVACTRIMA | P21 | Zone One |
| 63 | 3.40 | Sprinkler head completion / Zone One |  | 0.7d? | 2027-03-08 | 2027-03-08 | 51, 42 | 56.24d | 8.62d | Sprinkler crew [200%] | 11.25h | SPRTRIMA | P23S | Zone One |
| 64 | 3.41 | Alarm device completion / Zone One |  | 0.94d? | 2027-03-08 | 2027-03-09 | 51, 39 | 56.52d | 8.38d | Alarm specialist crew [200%] | 15h | ALARMTRIMA | P23A | Zone One |
| 65 | 3.42 | Furniture receiving and delivery / Zone One |  | 1d? | 2027-05-04 | 2027-05-05 | 17, 60, 57 | 8.15d | 0d | Logistics vendor crew [300%] | 24h | RECEIVEA | Supplier service | Zone One |
| 66 | 3.43 | Furniture assembly and placement / Zone One |  | 2.46d? | 2027-05-05 | 2027-05-10 | 65 | 8.15d | 0d | Furniture installation crew [300%] | 58.92h | FURNA | P12, P13, P14, P15, P16, P17 | Zone One |
| 67 | 3.44 | Data, AV and security completion / Zone One |  | 3.24d? | 2027-05-10 | 2027-05-13 | 66, 61, 40 | 8.15d |  | Data and AV crew [200%] | 51.8h | DATAFINA | P24 | Zone One |
| 68 | 3.45 | Concealed-work inspections / Zone Two |  | 2d? | 2027-02-26 | 2027-03-02 | 41, 37, 42, 39, 40 | 2.06d | 0d |  |  | ROUGHB | Coordination / waiting | Zone Two |
| 69 | 3.46 | Insulation and partition closure / Zone Two |  | 2.38d? | 2027-03-02 | 2027-03-04 | 68, 35, 47 | 2.06d | 0d | Partition crew [400%] | 76.26h | CLOSEB | P01 | Zone Two |
| 70 | 3.47 | Joint treatment and wall finishing / Zone Two |  | 0.87d? | 2027-03-04 | 2027-03-05 | 69 | 2.06d | 0d | Partition crew [400%] | 27.71h | JOINTB | P01 | Zone Two |

Notes:
- 2: Scope complete and accepted for the successor activity. / Planning allowance on the project working calendar; not a confirmed turnaround. Management/professional effort is not allocated here. / Text4: Planning allowance on the project working calendar; not a confirmed turnaround. Management/professional effort is not allocated here.
- 3: Scope complete and accepted for the successor activity. / Planning allowance on the project working calendar; not a confirmed turnaround. Management/professional effort is not allocated here. / Text4: Planning allowance on the project working calendar; not a confirmed turnaround. Management/professional effort is not allocated here.
- 4: Scope complete and accepted for the successor activity. / Planning allowance on the project working calendar; not a confirmed turnaround. Management/professional effort is not allocated here. / Text4: Planning allowance on the project working calendar; not a confirmed turnaround. Management/professional effort is not allocated here.
- 5: Scope complete and accepted for the successor activity. / Planning allowance on the project working calendar; not a confirmed turnaround. Management/professional effort is not allocated here. / Text4: Planning allowance on the project working calendar; not a confirmed turnaround. Management/professional effort is not allocated here.
- 6: Scope complete and accepted for the successor activity. / Planning allowance on the project working calendar; not a confirmed turnaround. Management/professional effort is not allocated here. / Text4: Planning allowance on the project working calendar; not a confirmed turnaround. Management/professional effort is not allocated here.
- 7: Scope complete and accepted for the successor activity. / Planning allowance on the project working calendar; not a confirmed turnaround. Management/professional effort is not allocated here. / Text4: Planning allowance on the project working calendar; not a confirmed turnaround. Management/professional effort is not allocated here.
- 8: Scope complete and accepted for the successor activity. / Planning allowance on the project working calendar; not a confirmed turnaround. Management/professional effort is not allocated here. / Text4: Planning allowance on the project working calendar; not a confirmed turnaround. Management/professional effort is not allocated here.
- 9: Scope complete and accepted for the successor activity. / Planning allowance on the project working calendar; not a confirmed turnaround. Management/professional effort is not allocated here. / Text4: Planning allowance on the project working calendar; not a confirmed turnaround. Management/professional effort is not allocated here.
- 10: Scope complete and accepted for the successor activity. / Planning allowance on the project working calendar; not a confirmed turnaround. Management/professional effort is not allocated here. / Text4: Planning allowance on the project working calendar; not a confirmed turnaround. Management/professional effort is not allocated here.
- 11: Scope complete and accepted for the successor activity. / Planning allowance on the project working calendar; not a confirmed turnaround. Management/professional effort is not allocated here. / Text4: Planning allowance on the project working calendar; not a confirmed turnaround. Management/professional effort is not allocated here.
- 12: Scope complete and accepted for the successor activity. / Planning allowance on the project working calendar; not a confirmed turnaround. Management/professional effort is not allocated here. / Text4: Planning allowance on the project working calendar; not a confirmed turnaround. Management/professional effort is not allocated here.
- 14: Scope complete and accepted for the successor activity. / Planning allowance on the project working calendar; not a confirmed turnaround. Management/professional effort is not allocated here. / Text4: Planning allowance on the project working calendar; not a confirmed turnaround. Management/professional effort is not allocated here.
- 15: Scope complete and accepted for the successor activity. / Planning allowance on the project working calendar; not a confirmed turnaround. Management/professional effort is not allocated here. / Text4: Planning allowance on the project working calendar; not a confirmed turnaround. Management/professional effort is not allocated here.
- 16: Scope complete and accepted for the successor activity. / Planning allowance on the project working calendar; not a confirmed turnaround. Management/professional effort is not allocated here. / Text4: Planning allowance on the project working calendar; not a confirmed turnaround. Management/professional effort is not allocated here.
- 17: Scope complete and accepted for the successor activity. / Planning allowance on the project working calendar; not a confirmed turnaround. Management/professional effort is not allocated here. / Text4: Planning allowance on the project working calendar; not a confirmed turnaround. Management/professional effort is not allocated here.
- 18: Scope complete and accepted for the successor activity. / Planning allowance on the project working calendar; not a confirmed turnaround. Management/professional effort is not allocated here. / Text4: Planning allowance on the project working calendar; not a confirmed turnaround. Management/professional effort is not allocated here.
- 19: Scope complete and accepted for the successor activity. / Planning allowance on the project working calendar; not a confirmed turnaround. Management/professional effort is not allocated here. / Text4: Planning allowance on the project working calendar; not a confirmed turnaround. Management/professional effort is not allocated here.
- 20: Provider service available for IT activation; access, circuits and contract confirmed. / Planning allowance on the project working calendar; not a confirmed turnaround. Management/professional effort is not allocated here. / Text4: Planning allowance on the project working calendar; not a confirmed turnaround. Management/professional effort is not allocated here.
- 21: Scope complete and accepted for the successor activity. / Planning allowance on the project working calendar; not a confirmed turnaround. Management/professional effort is not allocated here. / Text4: Planning allowance on the project working calendar; not a confirmed turnaround. Management/professional effort is not allocated here.
- 22: Scope complete and accepted for the successor activity. / Planning allowance on the project working calendar; not a confirmed turnaround. Management/professional effort is not allocated here. / Text4: Planning allowance on the project working calendar; not a confirmed turnaround. Management/professional effort is not allocated here.
- 24: Scope complete and accepted for the successor activity. / Estimated person-hours / assigned people; 8-hour working day. Crew availability requires confirmation. / Text4: Estimated person-hours / assigned people; 8-hour working day. Crew availability requires confirmation.
- 25: Scope complete and accepted for the successor activity. / Estimated person-hours / assigned people; 8-hour working day. Crew availability requires confirmation. / Text4: Estimated person-hours / assigned people; 8-hour working day. Crew availability requires confirmation.
- 26: Targeted support/penetration details and actual substrate reviewed before installation; no structural redesign assumed. / Estimated person-hours / assigned people; 8-hour working day. Crew availability requires confirmation. / Text4: Estimated person-hours / assigned people; 8-hour working day. Crew availability requires confirmation.
- 27: Scope complete and accepted for the successor activity. / Estimated person-hours / assigned people; 8-hour working day. Crew availability requires confirmation. Provisional equal allocation between two execution zones; separate access and inspection release required. / Text4: Estimated person-hours / assigned people; 8-hour working day. Crew availability requires confirmation. Provisional equal allocation between two execution zones; separate access and inspection release required.
- 28: Scope complete and accepted for the successor activity. / Estimated person-hours / assigned people; 8-hour working day. Crew availability requires confirmation. Provisional equal allocation between two execution zones; separate access and inspection release required. / Text4: Estimated person-hours / assigned people; 8-hour working day. Crew availability requires confirmation. Provisional equal allocation between two execution zones; separate access and inspection release required.
- 29: Scope complete and accepted for the successor activity. / Estimated person-hours / assigned people; 8-hour working day. Crew availability requires confirmation. Provisional equal allocation between two execution zones; separate access and inspection release required. / Text4: Estimated person-hours / assigned people; 8-hour working day. Crew availability requires confirmation. Provisional equal allocation between two execution zones; separate access and inspection release required.
- 30: Scope complete and accepted for the successor activity. / Estimated person-hours / assigned people; 8-hour working day. Crew availability requires confirmation. Provisional equal allocation between two execution zones; separate access and inspection release required. / Text4: Estimated person-hours / assigned people; 8-hour working day. Crew availability requires confirmation. Provisional equal allocation between two execution zones; separate access and inspection release required.
- 31: Scope complete and accepted for the successor activity. / Estimated person-hours / assigned people; 8-hour working day. Crew availability requires confirmation. Provisional equal allocation between two execution zones; separate access and inspection release required. / Text4: Estimated person-hours / assigned people; 8-hour working day. Crew availability requires confirmation. Provisional equal allocation between two execution zones; separate access and inspection release required.
- 32: Scope complete and accepted for the successor activity. / Estimated person-hours / assigned people; 8-hour working day. Crew availability requires confirmation. Provisional equal allocation between two execution zones; separate access and inspection release required. / Text4: Estimated person-hours / assigned people; 8-hour working day. Crew availability requires confirmation. Provisional equal allocation between two execution zones; separate access and inspection release required.
- 33: Scope complete and accepted for the successor activity. / Estimated person-hours / assigned people; 8-hour working day. Crew availability requires confirmation. Provisional equal allocation between two execution zones; separate access and inspection release required. / Text4: Estimated person-hours / assigned people; 8-hour working day. Crew availability requires confirmation. Provisional equal allocation between two execution zones; separate access and inspection release required.
- 34: Scope complete and accepted for the successor activity. / Estimated person-hours / assigned people; 8-hour working day. Crew availability requires confirmation. Provisional equal allocation between two execution zones; separate access and inspection release required. / Text4: Estimated person-hours / assigned people; 8-hour working day. Crew availability requires confirmation. Provisional equal allocation between two execution zones; separate access and inspection release required.
- 35: Scope complete and accepted for the successor activity. / Estimated person-hours / assigned people; 8-hour working day. Crew availability requires confirmation. Provisional equal allocation between two execution zones; separate access and inspection release required. / Text4: Estimated person-hours / assigned people; 8-hour working day. Crew availability requires confirmation. Provisional equal allocation between two execution zones; separate access and inspection release required.
- 36: Scope complete and accepted for the successor activity. / Estimated person-hours / assigned people; 8-hour working day. Crew availability requires confirmation. Provisional equal allocation between two execution zones; separate access and inspection release required. / Text4: Estimated person-hours / assigned people; 8-hour working day. Crew availability requires confirmation. Provisional equal allocation between two execution zones; separate access and inspection release required.
- 37: Scope complete and accepted for the successor activity. / Estimated person-hours / assigned people; 8-hour working day. Crew availability requires confirmation. Provisional equal allocation between two execution zones; separate access and inspection release required. / Text4: Estimated person-hours / assigned people; 8-hour working day. Crew availability requires confirmation. Provisional equal allocation between two execution zones; separate access and inspection release required.
- 38: Scope complete and accepted for the successor activity. / Estimated person-hours / assigned people; 8-hour working day. Crew availability requires confirmation. Provisional equal allocation between two execution zones; separate access and inspection release required. / Text4: Estimated person-hours / assigned people; 8-hour working day. Crew availability requires confirmation. Provisional equal allocation between two execution zones; separate access and inspection release required.
- 39: Scope complete and accepted for the successor activity. / Estimated person-hours / assigned people; 8-hour working day. Crew availability requires confirmation. Provisional equal allocation between two execution zones; separate access and inspection release required. / Text4: Estimated person-hours / assigned people; 8-hour working day. Crew availability requires confirmation. Provisional equal allocation between two execution zones; separate access and inspection release required.
- 40: Scope complete and accepted for the successor activity. / Estimated person-hours / assigned people; 8-hour working day. Crew availability requires confirmation. Provisional equal allocation between two execution zones; separate access and inspection release required. / Text4: Estimated person-hours / assigned people; 8-hour working day. Crew availability requires confirmation. Provisional equal allocation between two execution zones; separate access and inspection release required.
- 41: Scope complete and accepted for the successor activity. / Estimated person-hours / assigned people; 8-hour working day. Crew availability requires confirmation. Provisional equal allocation between two execution zones; separate access and inspection release required. / Text4: Estimated person-hours / assigned people; 8-hour working day. Crew availability requires confirmation. Provisional equal allocation between two execution zones; separate access and inspection release required.
- 42: Scope complete and accepted for the successor activity. / Estimated person-hours / assigned people; 8-hour working day. Crew availability requires confirmation. Provisional equal allocation between two execution zones; separate access and inspection release required. / Text4: Estimated person-hours / assigned people; 8-hour working day. Crew availability requires confirmation. Provisional equal allocation between two execution zones; separate access and inspection release required.
- 43: Scope complete and accepted for the successor activity. / Estimated person-hours / assigned people; 8-hour working day. Crew availability requires confirmation. / Text4: Estimated person-hours / assigned people; 8-hour working day. Crew availability requires confirmation.
- 44: Scope complete and accepted for the successor activity. / Estimated person-hours / assigned people; 8-hour working day. Crew availability requires confirmation. / Text4: Estimated person-hours / assigned people; 8-hour working day. Crew availability requires confirmation.
- 45: Scope complete and accepted for the successor activity. / Planning allowance on the project working calendar; not a confirmed turnaround. Management/professional effort is not allocated here. Provisional equal allocation between two execution zones; separate access and inspection release required. / Text4: Planning allowance on the project working calendar; not a confirmed turnaround. Management/professional effort is not allocated here. Provisional equal allocation between two execution zones; separate access and inspection release required.
- 46: Scope complete and accepted for the successor activity. / Estimated person-hours / assigned people; 8-hour working day. Crew availability requires confirmation. Provisional equal allocation between two execution zones; separate access and inspection release required. / Text4: Estimated person-hours / assigned people; 8-hour working day. Crew availability requires confirmation. Provisional equal allocation between two execution zones; separate access and inspection release required.
- 47: Scope complete and accepted for the successor activity. / Estimated person-hours / assigned people; 8-hour working day. Crew availability requires confirmation. Provisional equal allocation between two execution zones; separate access and inspection release required. / Text4: Estimated person-hours / assigned people; 8-hour working day. Crew availability requires confirmation. Provisional equal allocation between two execution zones; separate access and inspection release required.
- 48: Scope complete and accepted for the successor activity. / Planning allowance on the project working calendar; not a confirmed turnaround. Management/professional effort is not allocated here. Provisional equal allocation between two execution zones; separate access and inspection release required. / Text4: Planning allowance on the project working calendar; not a confirmed turnaround. Management/professional effort is not allocated here. Provisional equal allocation between two execution zones; separate access and inspection release required.
- 49: Scope complete and accepted for the successor activity. / Estimated person-hours / assigned people; 8-hour working day. Crew availability requires confirmation. Provisional equal allocation between two execution zones; separate access and inspection release required. / Text4: Estimated person-hours / assigned people; 8-hour working day. Crew availability requires confirmation. Provisional equal allocation between two execution zones; separate access and inspection release required.
- 50: Scope complete and accepted for the successor activity. / Estimated person-hours / assigned people; 8-hour working day. Crew availability requires confirmation. Provisional equal allocation between two execution zones; separate access and inspection release required. / Text4: Estimated person-hours / assigned people; 8-hour working day. Crew availability requires confirmation. Provisional equal allocation between two execution zones; separate access and inspection release required.
- 51: Scope complete and accepted for the successor activity. / Estimated person-hours / assigned people; 8-hour working day. Crew availability requires confirmation. Provisional equal allocation between two execution zones; separate access and inspection release required. / Text4: Estimated person-hours / assigned people; 8-hour working day. Crew availability requires confirmation. Provisional equal allocation between two execution zones; separate access and inspection release required.
- 52: Scope complete and accepted for the successor activity. / Estimated person-hours / assigned people; 8-hour working day. Crew availability requires confirmation. Provisional equal allocation between two execution zones; separate access and inspection release required. / Text4: Estimated person-hours / assigned people; 8-hour working day. Crew availability requires confirmation. Provisional equal allocation between two execution zones; separate access and inspection release required.
- 53: Scope complete and accepted for the successor activity. / Estimated person-hours / assigned people; 8-hour working day. Crew availability requires confirmation. Provisional equal allocation between two execution zones; separate access and inspection release required. / Text4: Estimated person-hours / assigned people; 8-hour working day. Crew availability requires confirmation. Provisional equal allocation between two execution zones; separate access and inspection release required.
- 54: Scope complete and accepted for the successor activity. / Planning allowance on the project working calendar; not a confirmed turnaround. Management/professional effort is not allocated here. Provisional equal allocation between two execution zones; separate access and inspection release required. / Text4: Planning allowance on the project working calendar; not a confirmed turnaround. Management/professional effort is not allocated here. Provisional equal allocation between two execution zones; separate access and inspection release required.
- 55: Scope complete and accepted for the successor activity. / Estimated person-hours / assigned people; 8-hour working day. Crew availability requires confirmation. Provisional equal allocation between two execution zones; separate access and inspection release required. / Text4: Estimated person-hours / assigned people; 8-hour working day. Crew availability requires confirmation. Provisional equal allocation between two execution zones; separate access and inspection release required.
- 56: Scope complete and accepted for the successor activity. / Estimated person-hours / assigned people; 8-hour working day. Crew availability requires confirmation. Provisional equal allocation between two execution zones; separate access and inspection release required. / Text4: Estimated person-hours / assigned people; 8-hour working day. Crew availability requires confirmation. Provisional equal allocation between two execution zones; separate access and inspection release required.
- 57: Scope complete and accepted for the successor activity. / Estimated person-hours / assigned people; 8-hour working day. Crew availability requires confirmation. Provisional equal allocation between two execution zones; separate access and inspection release required. / Text4: Estimated person-hours / assigned people; 8-hour working day. Crew availability requires confirmation. Provisional equal allocation between two execution zones; separate access and inspection release required.
- 58: Scope complete and accepted for the successor activity. / Estimated person-hours / assigned people; 8-hour working day. Crew availability requires confirmation. Provisional equal allocation between two execution zones; separate access and inspection release required. / Text4: Estimated person-hours / assigned people; 8-hour working day. Crew availability requires confirmation. Provisional equal allocation between two execution zones; separate access and inspection release required.
- 59: Scope complete and accepted for the successor activity. / Estimated person-hours / assigned people; 8-hour working day. Crew availability requires confirmation. Provisional equal allocation between two execution zones; separate access and inspection release required. / Text4: Estimated person-hours / assigned people; 8-hour working day. Crew availability requires confirmation. Provisional equal allocation between two execution zones; separate access and inspection release required.
- 60: Scope complete and accepted for the successor activity. / Estimated person-hours / assigned people; 8-hour working day. Crew availability requires confirmation. Provisional equal allocation between two execution zones; separate access and inspection release required. / Text4: Estimated person-hours / assigned people; 8-hour working day. Crew availability requires confirmation. Provisional equal allocation between two execution zones; separate access and inspection release required.
- 61: Scope complete and accepted for the successor activity. / Estimated person-hours / assigned people; 8-hour working day. Crew availability requires confirmation. Provisional equal allocation between two execution zones; separate access and inspection release required. / Text4: Estimated person-hours / assigned people; 8-hour working day. Crew availability requires confirmation. Provisional equal allocation between two execution zones; separate access and inspection release required.
- 62: Scope complete and accepted for the successor activity. / Estimated person-hours / assigned people; 8-hour working day. Crew availability requires confirmation. Provisional equal allocation between two execution zones; separate access and inspection release required. / Text4: Estimated person-hours / assigned people; 8-hour working day. Crew availability requires confirmation. Provisional equal allocation between two execution zones; separate access and inspection release required.
- 63: Scope complete and accepted for the successor activity. / Estimated person-hours / assigned people; 8-hour working day. Crew availability requires confirmation. Provisional equal allocation between two execution zones; separate access and inspection release required. / Text4: Estimated person-hours / assigned people; 8-hour working day. Crew availability requires confirmation. Provisional equal allocation between two execution zones; separate access and inspection release required.
- 64: Scope complete and accepted for the successor activity. / Estimated person-hours / assigned people; 8-hour working day. Crew availability requires confirmation. Provisional equal allocation between two execution zones; separate access and inspection release required. / Text4: Estimated person-hours / assigned people; 8-hour working day. Crew availability requires confirmation. Provisional equal allocation between two execution zones; separate access and inspection release required.
- 65: Scope complete and accepted for the successor activity. / Supplier staffing allowance already included in the all-in service budget; not additional cost. Provisional equal allocation between two execution zones; separate access and inspection release required. / Text4: Supplier staffing allowance already included in the all-in service budget; not additional cost. Provisional equal allocation between two execution zones; separate access and inspection release required.
- 66: Scope complete and accepted for the successor activity. / Estimated person-hours / assigned people; 8-hour working day. Crew availability requires confirmation. Provisional equal allocation between two execution zones; separate access and inspection release required. / Text4: Estimated person-hours / assigned people; 8-hour working day. Crew availability requires confirmation. Provisional equal allocation between two execution zones; separate access and inspection release required.
- 67: Scope complete and accepted for the successor activity. / Estimated person-hours / assigned people; 8-hour working day. Crew availability requires confirmation. Provisional equal allocation between two execution zones; separate access and inspection release required. / Text4: Estimated person-hours / assigned people; 8-hour working day. Crew availability requires confirmation. Provisional equal allocation between two execution zones; separate access and inspection release required.
- 68: Scope complete and accepted for the successor activity. / Planning allowance on the project working calendar; not a confirmed turnaround. Management/professional effort is not allocated here. Provisional equal allocation between two execution zones; separate access and inspection release required. / Text4: Planning allowance on the project working calendar; not a confirmed turnaround. Management/professional effort is not allocated here. Provisional equal allocation between two execution zones; separate access and inspection release required.
- 69: Scope complete and accepted for the successor activity. / Estimated person-hours / assigned people; 8-hour working day. Crew availability requires confirmation. Provisional equal allocation between two execution zones; separate access and inspection release required. / Text4: Estimated person-hours / assigned people; 8-hour working day. Crew availability requires confirmation. Provisional equal allocation between two execution zones; separate access and inspection release required.
- 70: Scope complete and accepted for the successor activity. / Estimated person-hours / assigned people; 8-hour working day. Crew availability requires confirmation. Provisional equal allocation between two execution zones; separate access and inspection release required. / Text4: Estimated person-hours / assigned people; 8-hour working day. Crew availability requires confirmation. Provisional equal allocation between two execution zones; separate access and inspection release required.

| ID | WBS | Task | Type | Duration | Start | Finish | Predecessors | Total slack | Free slack | Resources | Work | Text1 | Text2 | Text3 |
| --- | --- | --- | --- | --- | --- | --- | --- | --- | --- | --- | --- | --- | --- | --- |
| 71 | 3.48 | Drying and substrate acceptance / Zone Two |  | 2d? | 2027-03-05 | 2027-03-09 | 70 | 2.06d | 0d |  |  | DRYB | Coordination / waiting | Zone Two |
| 72 | 3.49 | Painting and finish protection / Zone Two |  | 1.61d? | 2027-03-09 | 2027-03-10 | 71, 49 | 2.06d | 0d | Painting crew [300%] | 38.57h | PAINTB | P09 | Zone Two |
| 73 | 3.50 | Ceiling grid and tiles / Zone Two |  | 4.64d? | 2027-03-10 | 2027-03-17 | 72, 19, 51 | 2.06d | 0d | Ceiling crew [300%] | 111.32h | CEILB | P05 | Zone Two |
| 74 | 3.51 | Suspended acoustic baffles / Zone Two |  | 1.88d? | 2027-03-17 | 2027-03-19 | 73 | 2.06d | 0d | Ceiling crew [300%] | 45h | BAFFLEB | P06 | Zone Two |
| 75 | 3.52 | Floor preparation and patching / Zone Two |  | 2.5d? | 2027-03-19 | 2027-03-23 | 74 | 2.06d | 0d | Flooring crew B [300%] | 60h | PREPFLOORB | P07 | Zone Two |
| 76 | 3.53 | Porcelain floor installation / Zone Two |  | 23.78d? | 2027-03-23 | 2027-04-26 | 75 | 2.06d | 0d | Flooring crew B [300%] | 570.78h | TILEB | P07 | Zone Two |
| 77 | 3.54 | Floor cure and finish acceptance / Zone Two |  | 2d? | 2027-04-26 | 2027-04-28 | 76 | 2.06d | 0d |  |  | CUREB | Coordination / waiting | Zone Two |
| 78 | 3.55 | Carpet tile and transitions / Zone Two |  | 2.15d? | 2027-04-28 | 2027-04-30 | 77 | 2.06d | 0d | Flooring crew B [300%] | 51.66h | CARPETB | P08 | Zone Two |
| 79 | 3.56 | Glazed partitions and seals / Zone Two |  | 7.8d? | 2027-05-03 | 2027-05-13 | 78, 15, 57 | 3.42d | 0d | Glazing crew [300%] | 187.24h | GLASSB | P02 | Zone Two |
| 80 | 3.57 | Glass doors and hardware / Zone Two |  | 1.88d? | 2027-05-13 | 2027-05-14 | 79 | 3.42d |  | Glazing crew [200%] | 30h | GLASSDOORB | P03 | Zone Two |
| 81 | 3.58 | Solid doors and hardware / Zone Two |  | 0.47d? | 2027-05-04 | 2027-05-05 | 78, 15, 60 | 0d |  | Millwork crew [200%] | 7.5h | SOLIDDOORB | P04 | Zone Two |
| 82 | 3.59 | Fixed millwork and pantry joinery / Zone Two |  | 5.83d? | 2027-05-05 | 2027-05-13 | 81, 16 | 0d |  | Millwork crew [300%] | 140h | MILLB | P11 | Zone Two |
| 83 | 3.60 | Decorative finishes, shading and signs / Zone Two |  | 5.08d? | 2027-05-13 | 2027-05-20 | 82 | 0d |  | Millwork crew [300%] | 122h | DECORB | P10 | Zone Two |
| 84 | 3.61 | Electrical trim, controls and fixtures / Zone Two |  | 4.59d? | 2027-04-30 | 2027-05-07 | 78, 41, 61 | 10.55d | 0d | Electrical crew [300%] | 110.1h | ELECTRIMB | P19, P20 | Zone Two |
| 85 | 3.62 | Air terminals and controls completion / Zone Two |  | 2.33d? | 2027-03-19 | 2027-03-23 | 74, 37, 62 | 44.08d | 33.52d | HVAC crew [300%] | 56h | HVACTRIMB | P21 | Zone Two |
| 86 | 3.63 | Sprinkler head completion / Zone Two |  | 0.7d? | 2027-03-19 | 2027-03-22 | 74, 42, 63 | 47.62d | 0d | Sprinkler crew [200%] | 11.25h | SPRTRIMB | P23S | Zone Two |
| 87 | 3.64 | Alarm device completion / Zone Two |  | 0.94d? | 2027-03-19 | 2027-03-22 | 74, 39, 64 | 48.14d | 37.59d | Alarm specialist crew [200%] | 15h | ALARMTRIMB | P23A | Zone Two |
| 88 | 3.65 | Furniture receiving and delivery / Zone Two |  | 1d? | 2027-05-20 | 2027-05-21 | 17, 83, 80, 65 | 0d |  | Logistics vendor crew [300%] | 24h | RECEIVEB | Supplier service | Zone Two |
| 89 | 3.66 | Furniture assembly and placement / Zone Two |  | 2.46d? | 2027-05-21 | 2027-05-25 | 88, 66 | 0d |  | Furniture installation crew [300%] | 58.92h | FURNB | P12, P13, P14, P15, P16, P17 | Zone Two |
| 90 | 3.67 | Data, AV and security completion / Zone Two |  | 3.24d? | 2027-05-25 | 2027-05-28 | 89, 84, 40, 67 | 0d |  | Data and AV crew [200%] | 51.8h | DATAFINB | P24 | Zone Two |
| 91 | 3.68 | Pantry fixture connection and tie-in |  | 2.38d? | 2027-04-27 | 2027-04-30 | 59, 44 | 19.74d | 0d | Plumbing crew [200%] | 38h | PLUMBFIN | P22 | Whole office |
| 92 | 3.69 | Pantry appliances and opening supplies |  | 0.5d? | 2027-04-30 | 2027-04-30 | 91, 61, 21 | 19.74d | 17.05d | Site support crew [200%] | 8h | APPLIANCE | P27 | Whole office |
| 93 | 3.70 | Plants, planters and safety accessories |  | 0.55d? | 2027-05-25 | 2027-05-26 | 66, 89, 92 | 2.69d |  | Furniture installation crew [300%] | 13.1h | STYLING | P18, P28 | Whole office |
| 94 | 4 | **04 Testing and physical completion** |  | 60.87d? | 2027-03-22 | 2027-06-15 |  | 2.33d |  |  | 264h |  |  |  |
| 95 | 4.1 | Power tests and shutdown verification |  | 0.83d? | 2027-05-07 | 2027-05-10 | 61, 84 | 10.55d | 0d | Electrical crew [300%] | 20h | POWERTEST | P20 | Whole office |
| 96 | 4.2 | HVAC balancing and functional tests |  | 2.67d? | 2027-05-10 | 2027-05-12 | 62, 85, 95 | 10.55d | 0d | HVAC crew [300%] | 64h | TAB | P21 | Whole office |
| 97 | 4.3 | Sprinkler tests and acceptance support |  | 0.75d? | 2027-03-22 | 2027-03-22 | 63, 86 | 47.62d | 37.07d | Sprinkler crew [200%] | 12h | SPRTEST | P23S | Whole office |
| 98 | 4.4 | Alarm programming and interface tests |  | 1.5d? | 2027-05-12 | 2027-05-14 | 64, 87, 95, 96, 97 | 10.55d |  | Alarm specialist crew [200%] | 24h | ALARMTEST | P23A | Whole office |
| 99 | 4.5 | Integrated checks and punch corrections |  | 2.33d? | 2027-06-01 | 2027-06-03 | 96, 98, 97, 91, 67, 90, 93 | 0d |  | Site support crew [300%] | 56h | PUNCH | P25 | Whole office |
| 100 | 4.6 | Final trade inspections |  | 3d? | 2027-06-03 | 2027-06-08 | 99 | 0d |  |  |  | FINAL | Coordination / waiting | Whole office |
| 101 | 4.7 | Inspection corrections and field handover |  | 1d? | 2027-06-08 | 2027-06-09 | 100 | 0d |  | Site support crew [300%] | 24h | CORRECT | P25 | Whole office |
| 102 | 4.8 | Inspection closeout / reinspection |  | 2d? | 2027-06-09 | 2027-06-11 | 101 | 0d |  |  |  | REINSPECT | Coordination / waiting | Whole office |
| 103 | 4.9 | Final construction cleaning |  | 2.67d? | 2027-06-11 | 2027-06-15 | 102 | 2.33d | 0d | Site support crew [300%] | 64h | CLEAN | P25 | Whole office |
| 104 | 4.10 | Physical completion and field release | milestone | 0d | 2027-06-15 | 2027-06-15 | 103 | 2.33d |  |  |  | FIELDEND | Coordination / waiting | Whole office |

Notes:
- 71: Scope complete and accepted for the successor activity. / Planning allowance on the project working calendar; not a confirmed turnaround. Management/professional effort is not allocated here. Provisional equal allocation between two execution zones; separate access and inspection release required. / Text4: Planning allowance on the project working calendar; not a confirmed turnaround. Management/professional effort is not allocated here. Provisional equal allocation between two execution zones; separate access and inspection release required.
- 72: Scope complete and accepted for the successor activity. / Estimated person-hours / assigned people; 8-hour working day. Crew availability requires confirmation. Provisional equal allocation between two execution zones; separate access and inspection release required. / Text4: Estimated person-hours / assigned people; 8-hour working day. Crew availability requires confirmation. Provisional equal allocation between two execution zones; separate access and inspection release required.
- 73: Scope complete and accepted for the successor activity. / Estimated person-hours / assigned people; 8-hour working day. Crew availability requires confirmation. Provisional equal allocation between two execution zones; separate access and inspection release required. / Text4: Estimated person-hours / assigned people; 8-hour working day. Crew availability requires confirmation. Provisional equal allocation between two execution zones; separate access and inspection release required.
- 74: Scope complete and accepted for the successor activity. / Estimated person-hours / assigned people; 8-hour working day. Crew availability requires confirmation. Provisional equal allocation between two execution zones; separate access and inspection release required. / Text4: Estimated person-hours / assigned people; 8-hour working day. Crew availability requires confirmation. Provisional equal allocation between two execution zones; separate access and inspection release required.
- 75: Scope complete and accepted for the successor activity. / Estimated person-hours / assigned people; 8-hour working day. Crew availability requires confirmation. Provisional equal allocation between two execution zones; separate access and inspection release required. / Text4: Estimated person-hours / assigned people; 8-hour working day. Crew availability requires confirmation. Provisional equal allocation between two execution zones; separate access and inspection release required.
- 76: Scope complete and accepted for the successor activity. / Estimated person-hours / assigned people; 8-hour working day. Crew availability requires confirmation. Provisional equal allocation between two execution zones; separate access and inspection release required. / Text4: Estimated person-hours / assigned people; 8-hour working day. Crew availability requires confirmation. Provisional equal allocation between two execution zones; separate access and inspection release required.
- 77: Scope complete and accepted for the successor activity. / Planning allowance on the project working calendar; not a confirmed turnaround. Management/professional effort is not allocated here. Provisional equal allocation between two execution zones; separate access and inspection release required. / Text4: Planning allowance on the project working calendar; not a confirmed turnaround. Management/professional effort is not allocated here. Provisional equal allocation between two execution zones; separate access and inspection release required.
- 78: Scope complete and accepted for the successor activity. / Estimated person-hours / assigned people; 8-hour working day. Crew availability requires confirmation. Provisional equal allocation between two execution zones; separate access and inspection release required. / Text4: Estimated person-hours / assigned people; 8-hour working day. Crew availability requires confirmation. Provisional equal allocation between two execution zones; separate access and inspection release required.
- 79: Scope complete and accepted for the successor activity. / Estimated person-hours / assigned people; 8-hour working day. Crew availability requires confirmation. Provisional equal allocation between two execution zones; separate access and inspection release required. / Text4: Estimated person-hours / assigned people; 8-hour working day. Crew availability requires confirmation. Provisional equal allocation between two execution zones; separate access and inspection release required.
- 80: Scope complete and accepted for the successor activity. / Estimated person-hours / assigned people; 8-hour working day. Crew availability requires confirmation. Provisional equal allocation between two execution zones; separate access and inspection release required. / Text4: Estimated person-hours / assigned people; 8-hour working day. Crew availability requires confirmation. Provisional equal allocation between two execution zones; separate access and inspection release required.
- 81: Scope complete and accepted for the successor activity. / Estimated person-hours / assigned people; 8-hour working day. Crew availability requires confirmation. Provisional equal allocation between two execution zones; separate access and inspection release required. / Text4: Estimated person-hours / assigned people; 8-hour working day. Crew availability requires confirmation. Provisional equal allocation between two execution zones; separate access and inspection release required.
- 82: Scope complete and accepted for the successor activity. / Estimated person-hours / assigned people; 8-hour working day. Crew availability requires confirmation. Provisional equal allocation between two execution zones; separate access and inspection release required. / Text4: Estimated person-hours / assigned people; 8-hour working day. Crew availability requires confirmation. Provisional equal allocation between two execution zones; separate access and inspection release required.
- 83: Scope complete and accepted for the successor activity. / Estimated person-hours / assigned people; 8-hour working day. Crew availability requires confirmation. Provisional equal allocation between two execution zones; separate access and inspection release required. / Text4: Estimated person-hours / assigned people; 8-hour working day. Crew availability requires confirmation. Provisional equal allocation between two execution zones; separate access and inspection release required.
- 84: Scope complete and accepted for the successor activity. / Estimated person-hours / assigned people; 8-hour working day. Crew availability requires confirmation. Provisional equal allocation between two execution zones; separate access and inspection release required. / Text4: Estimated person-hours / assigned people; 8-hour working day. Crew availability requires confirmation. Provisional equal allocation between two execution zones; separate access and inspection release required.
- 85: Scope complete and accepted for the successor activity. / Estimated person-hours / assigned people; 8-hour working day. Crew availability requires confirmation. Provisional equal allocation between two execution zones; separate access and inspection release required. / Text4: Estimated person-hours / assigned people; 8-hour working day. Crew availability requires confirmation. Provisional equal allocation between two execution zones; separate access and inspection release required.
- 86: Scope complete and accepted for the successor activity. / Estimated person-hours / assigned people; 8-hour working day. Crew availability requires confirmation. Provisional equal allocation between two execution zones; separate access and inspection release required. / Text4: Estimated person-hours / assigned people; 8-hour working day. Crew availability requires confirmation. Provisional equal allocation between two execution zones; separate access and inspection release required.
- 87: Scope complete and accepted for the successor activity. / Estimated person-hours / assigned people; 8-hour working day. Crew availability requires confirmation. Provisional equal allocation between two execution zones; separate access and inspection release required. / Text4: Estimated person-hours / assigned people; 8-hour working day. Crew availability requires confirmation. Provisional equal allocation between two execution zones; separate access and inspection release required.
- 88: Scope complete and accepted for the successor activity. / Supplier staffing allowance already included in the all-in service budget; not additional cost. Provisional equal allocation between two execution zones; separate access and inspection release required. / Text4: Supplier staffing allowance already included in the all-in service budget; not additional cost. Provisional equal allocation between two execution zones; separate access and inspection release required.
- 89: Scope complete and accepted for the successor activity. / Estimated person-hours / assigned people; 8-hour working day. Crew availability requires confirmation. Provisional equal allocation between two execution zones; separate access and inspection release required. / Text4: Estimated person-hours / assigned people; 8-hour working day. Crew availability requires confirmation. Provisional equal allocation between two execution zones; separate access and inspection release required.
- 90: Scope complete and accepted for the successor activity. / Estimated person-hours / assigned people; 8-hour working day. Crew availability requires confirmation. Provisional equal allocation between two execution zones; separate access and inspection release required. / Text4: Estimated person-hours / assigned people; 8-hour working day. Crew availability requires confirmation. Provisional equal allocation between two execution zones; separate access and inspection release required.
- 91: Scope complete and accepted for the successor activity. / Estimated person-hours / assigned people; 8-hour working day. Crew availability requires confirmation. / Text4: Estimated person-hours / assigned people; 8-hour working day. Crew availability requires confirmation.
- 92: Scope complete and accepted for the successor activity. / Estimated person-hours / assigned people; 8-hour working day. Crew availability requires confirmation. / Text4: Estimated person-hours / assigned people; 8-hour working day. Crew availability requires confirmation.
- 93: Scope complete and accepted for the successor activity. / Estimated person-hours / assigned people; 8-hour working day. Crew availability requires confirmation. / Text4: Estimated person-hours / assigned people; 8-hour working day. Crew availability requires confirmation.
- 95: Scope complete and accepted for the successor activity. / Estimated person-hours / assigned people; 8-hour working day. Crew availability requires confirmation. / Text4: Estimated person-hours / assigned people; 8-hour working day. Crew availability requires confirmation.
- 96: Scope complete and accepted for the successor activity. / Estimated person-hours / assigned people; 8-hour working day. Crew availability requires confirmation. / Text4: Estimated person-hours / assigned people; 8-hour working day. Crew availability requires confirmation.
- 97: Scope complete and accepted for the successor activity. / Estimated person-hours / assigned people; 8-hour working day. Crew availability requires confirmation. / Text4: Estimated person-hours / assigned people; 8-hour working day. Crew availability requires confirmation.
- 98: Scope complete and accepted for the successor activity. / Estimated person-hours / assigned people; 8-hour working day. Crew availability requires confirmation. / Text4: Estimated person-hours / assigned people; 8-hour working day. Crew availability requires confirmation.
- 99: Scope complete and accepted for the successor activity. / Estimated person-hours / assigned people; 8-hour working day. Crew availability requires confirmation. / Text4: Estimated person-hours / assigned people; 8-hour working day. Crew availability requires confirmation.
- 100: Scope complete and accepted for the successor activity. / Planning allowance on the project working calendar; not a confirmed turnaround. Management/professional effort is not allocated here. / Text4: Planning allowance on the project working calendar; not a confirmed turnaround. Management/professional effort is not allocated here.
- 101: Scope complete and accepted for the successor activity. / Estimated person-hours / assigned people; 8-hour working day. Crew availability requires confirmation. / Text4: Estimated person-hours / assigned people; 8-hour working day. Crew availability requires confirmation.
- 102: Scope complete and accepted for the successor activity. / Planning allowance on the project working calendar; not a confirmed turnaround. Management/professional effort is not allocated here. / Text4: Planning allowance on the project working calendar; not a confirmed turnaround. Management/professional effort is not allocated here.
- 103: Scope complete and accepted for the successor activity. / Estimated person-hours / assigned people; 8-hour working day. Crew availability requires confirmation. / Text4: Estimated person-hours / assigned people; 8-hour working day. Crew availability requires confirmation.
- 104: Scope complete and accepted for the successor activity. / Planning allowance on the project working calendar; not a confirmed turnaround. Management/professional effort is not allocated here. / Text4: Planning allowance on the project working calendar; not a confirmed turnaround. Management/professional effort is not allocated here.

| ID | WBS | Task | Type | Duration | Start | Finish | Predecessors | Total slack | Resources | Work | Text1 | Text2 | Text3 |
| --- | --- | --- | --- | --- | --- | --- | --- | --- | --- | --- | --- | --- | --- |
| 105 | 5 | **05 Operational readiness and handover** |  | 17d? | 2027-06-03 | 2027-06-28 |  | 0d |  | 96h |  |  |  |
| 106 | 5.1 | As-builts, warranties and O&M records |  | 3d? | 2027-06-03 | 2027-06-08 | 99 | 3d |  |  | RECORDS | Coordination / waiting | Whole office |
| 107 | 5.2 | Required completion / occupancy release |  | 5d? | 2027-06-11 | 2027-06-18 | 102, 106 | 0d |  |  | OCCUPY | Coordination / waiting | Whole office |
| 108 | 5.3 | Applicable business opening requirements |  | 5d? | 2027-06-18 | 2027-06-25 | 107 | 1d |  |  | BUSINESS | Coordination / waiting | Whole office |
| 109 | 5.4 | Move and occupancy setup |  | 2d? | 2027-06-18 | 2027-06-22 | 104, 107 | 0d | Logistics vendor crew [300%] | 48h | MOVE | Supplier service | Whole office |
| 110 | 5.5 | Computer deployment and service activation |  | 3d? | 2027-06-22 | 2027-06-25 | 109, 20, 67, 90, 21 | 0d | IT deployment vendor [200%] | 48h | ITACTIVATE | Supplier service | Whole office |
| 111 | 5.6 | User familiarization and handover review |  | 1d? | 2027-06-25 | 2027-06-28 | 110, 106 | 0d |  |  | TRAIN | Coordination / waiting | Whole office |
| 112 | 5.7 | Operational acceptance | milestone | 0d | 2027-06-28 | 2027-06-28 | 111, 108 | 0d |  |  | READY | Coordination / waiting | Whole office |

Notes:
- 106: Scope complete and accepted for the successor activity. / Planning allowance on the project working calendar; not a confirmed turnaround. Management/professional effort is not allocated here. / Text4: Planning allowance on the project working calendar; not a confirmed turnaround. Management/professional effort is not allocated here.
- 107: Scope complete and accepted for the successor activity. / Planning allowance on the project working calendar; not a confirmed turnaround. Management/professional effort is not allocated here. / Text4: Planning allowance on the project working calendar; not a confirmed turnaround. Management/professional effort is not allocated here.
- 108: Scope complete and accepted for the successor activity. / Planning allowance on the project working calendar; not a confirmed turnaround. Management/professional effort is not allocated here. / Text4: Planning allowance on the project working calendar; not a confirmed turnaround. Management/professional effort is not allocated here.
- 109: Scope complete and accepted for the successor activity. / Supplier staffing allowance already included in the all-in service budget; not additional cost. / Text4: Supplier staffing allowance already included in the all-in service budget; not additional cost.
- 110: Scope complete and accepted for the successor activity. / Supplier staffing allowance already included in the all-in service budget; not additional cost. / Text4: Supplier staffing allowance already included in the all-in service budget; not additional cost.
- 111: Scope complete and accepted for the successor activity. / Planning allowance on the project working calendar; not a confirmed turnaround. Management/professional effort is not allocated here. / Text4: Planning allowance on the project working calendar; not a confirmed turnaround. Management/professional effort is not allocated here.
- 112: Scope complete and accepted for the successor activity. / Planning allowance on the project working calendar; not a confirmed turnaround. Management/professional effort is not allocated here. / Text4: Planning allowance on the project working calendar; not a confirmed turnaround. Management/professional effort is not allocated here.
